# Kitchen Replacement Project

Schedule from MS Project, 2013-10-07 to 2013-10-18.

## Calendars

- Standard: Mon-Fri 08:00-12:00, 13:00-17:00; Sat-Sun off.

## Schedule

| ID | WBS | Task | Duration | Start | Finish | Predecessors | Total slack | Free slack |
| --- | --- | --- | --- | --- | --- | --- | --- | --- |
| 1 | 1 | Design/Procure | 1d | 2013-10-07 | 2013-10-07 |  | 9d |  |
| 2 | 2 | **Tear Out/Prep** | 10d | 2013-10-07 | 2013-10-18 |  | 0d |  |
| 3 | 2.1 | Disc & remove Burners | 2d | 2013-10-07 | 2013-10-08 |  | 0d |  |
| 4 | 2.2 | Disc & Remove sink /faucets | 1d | 2013-10-07 | 2013-10-07 |  | 1d |  |
| 5 | 2.3 | Disc & remove oven | 1d | 2013-10-07 | 2013-10-07 |  | 2d | 0d |
| 6 | 2.4 | Remove countertop | 1d | 2013-10-09 | 2013-10-09 | 3, 4 | 0d |  |
| 7 | 2.5 | Remove lwr Cabinets | 2d | 2013-10-10 | 2013-10-11 | 6 | 0d |  |
| 8 | 2.6 | Remove Upper Cabinets | 1d | 2013-10-08 | 2013-10-08 | 5 | 2d | 0d |
| 9 | 2.7 | Remove soffit | 1d | 2013-10-09 | 2013-10-09 | 8 | 2d |  |
| 10 | 2.8 | Remove drywall behind cupboards | 1d | 2013-10-14 | 2013-10-14 | 7, 9 | 0d |  |
| 11 | 2.9 | Remove floor tile | 1d | 2013-10-14 | 2013-10-14 | 7, 9 | 2d |  |
| 12 | 2.10 | Rough In Elec | 2d | 2013-10-15 | 2013-10-16 | 10 | 0d |  |
| 13 | 2.11 | Rough In Plumbing | 1d | 2013-10-15 | 2013-10-15 | 10 | 1d |  |
| 14 | 2.12 | Install new Drywall | 1d | 2013-10-17 | 2013-10-17 | 11, 12, 13 | 0d |  |
| 15 | 2.13 | Paint | 1d | 2013-10-18 | 2013-10-18 | 14 | 0d |  |
| 16 | 3 | Install | 1d? | 2013-10-07 | 2013-10-07 |  | 9d |  |
| 17 | 4 | Close | 1d? | 2013-10-07 | 2013-10-07 |  | 9d |  |
